# MAPS Inner Barrel

How a schedule from MS Project changed from version to version. A marks actual dates.

## Version 1 (saved 2016-08-10, file MAPS_Inner_Barrel-2016_07_27.mpp)

| ID | WBS | Task | Duration | Start | Finish | Predecessors | Total float | Constraint |
| --- | --- | --- | --- | --- | --- | --- | --- | --- |
| 1 | 1 | **MAPS Inner Barrel** | 1218d | 2016-10-01 | 2021-06-01 |  |  | start no earlier than 2005-10-21 |
| 2 | 1.1 | **Milestones** | 1216d | 2016-10-01 | 2021-06-01 |  | 0d |  |
| 3 |  | sPHENIX Conceptual Design (CD-0) | 0d | 2016-10-01 | 2016-10-01 |  |  | start no earlier than 2016-10-01 |
| 4 |  | sPHENIX Technical Design (CD-1) | 0d | 2017-11-01 | 2017-11-01 |  |  | start no earlier than 2017-11-01 |
| 5 |  | sPHENIX Final Design (CD-2/CD-3a) | 0d | 2018-06-01 | 2018-06-01 | 96 |  | start no earlier than 2018-06-01 |
| 6 |  | sPHENIX Start Construction (CD-3b) | 0d | 2018-08-01 | 2018-08-01 |  |  | start no earlier than 2018-08-01 |
| 7 |  | sPHENIX Installation | 0d | 2021-06-01 | 2021-06-01 | 122 |  | start no earlier than 2021-06-01 |
| 8 |  | ALICE ITS Inner Barrel Construction | 261d | 2017-01-02 | 2018-01-01 |  |  | finish no earlier than 2018-01-01 |
| 9 |  | ALICE ITS Electronics Pre-Production | 100d | 2017-02-22 | 2017-07-11 |  |  | finish no earlier than 2017-07-11 |
| 10 |  | ALICE ITS Electronics Production | 240d | 2017-07-13 | 2018-06-13 | 9 |  | start no earlier than 2017-07-12 |
| 11 |  | LANL LDRD | 781d | 2016-10-03 | 2019-09-30 |  |  | finish no earlier than 2019-09-30 |
| 12 |  | sPHENIX Test Beam | 21d | 2019-02-01 | 2019-03-01 |  |  |  |
| 13 | 1.2 | **Project Management** | 1217d | 2016-10-03 | 2021-06-01 |  | 0d |  |
| 14 |  | Level 3 Project Manager | 1217d | 2016-10-03 | 2021-06-01 |  | 0d | finish no earlier than 2021-06-01 |
| 15 |  | Mechanical Liason Engineer | 1217d | 2016-10-03 | 2021-06-01 |  | 0d | finish no earlier than 2021-06-01 |
| 16 |  | Electronics Liason Engineer | 1217d | 2016-10-03 | 2021-06-01 |  | 0d | finish no earlier than 2021-06-01 |
| 17 | 1.3 | **Design & Prototyping** | 363d | 2016-10-03 | 2018-02-21 |  | 333d |  |
| 18 | 1.3.1 | **Readout Test Stand** | 35d | 2016-10-03 | 2016-11-18 |  | 414d |  |
| 19 |  | Design | 0d | 2016-10-03 | 2016-10-03 |  | 414d | start no earlier than 2016-10-03 |
| 20 |  | Procure 2 Stands | 30d | 2016-10-03 | 2016-11-11 | 19 | 414d |  |
| 21 |  | Setup | 5d | 2016-11-14 | 2016-11-18 | 20 | 414d |  |
| 22 | 1.3.2 | **Detector Staves** | 95d | 2017-07-31 | 2017-12-08 | 8SS+150d, 18 | 234d |  |
| 23 |  | Procure 4 Staves | 90d | 2017-07-31 | 2017-12-01 |  | 234d |  |
| 24 |  | Test Staves | 5d | 2017-12-04 | 2017-12-08 | 23 | 234d |  |
| 25 | 1.3.3 | **Electronics** | 363d | 2016-10-03 | 2018-02-21 |  | 333d |  |
| 26 | 1.3.3.1 | **ALICE Readout Electronics** | 264d | 2016-10-03 | 2017-10-05 |  | 929d |  |
| 27 | 1.3.3.1.1 | **SamTec Cables** | 62d | 2016-10-03 | 2016-12-27 |  | 1007d |  |
| 28 |  | Procure 7 SamTec Cables | 60d | 2016-10-03 | 2016-12-23 |  | 1007d |  |
| 29 |  | Test Cables | 2d | 2016-12-26 | 2016-12-27 | 28 | 1007d |  |
| 30 | 1.3.3.1.2 | **Readout Units (RDOs)** | 62d | 2017-07-12 | 2017-10-05 | 9 | 929d |  |
| 31 |  | Procure 4 RDOs | 60d | 2017-07-12 | 2017-10-03 |  | 929d |  |
| 32 |  | Test RDOs | 2d | 2017-10-04 | 2017-10-05 | 31 | 929d |  |
| 33 | 1.3.3.1.3 | **Optical Cables** | 62d | 2016-12-28 | 2017-03-23 | 27 | 1007d |  |
| 34 |  | Procure 4 Optical Cables | 60d | 2016-12-28 | 2017-03-21 |  | 1007d |  |
| 35 |  | Test Optical Cables | 2d | 2017-03-22 | 2017-03-23 | 34 | 1007d |  |
| 36 | 1.3.3.1.4 | **Common Readout Units (CRUs)** | 62d | 2017-03-24 | 2017-06-19 | 33 | 1007d |  |
| 37 |  | Procure 2 CRUs | 60d | 2017-03-24 | 2017-06-15 |  | 1007d |  |
| 38 |  | Test CRUs | 2d | 2017-06-16 | 2017-06-19 | 37 | 1007d |  |
| 39 | 1.3.3.2 | **sPHENIX Readout Electronics** | 351d | 2016-10-03 | 2018-02-05 |  | 333d |  |
| 40 |  | obtain ALICE Readout Unit design | 1d | 2016-10-03 | 2016-10-03 |  | 333d |  |
| 41 |  | initial design | 40d | 2016-10-04 | 2016-11-28 | 40 | 333d |  |
| 42 |  | prototype | 60d | 2016-11-29 | 2017-02-20 | 41 | 333d |  |
| 43 |  | test | 20d | 2017-02-21 | 2017-03-20 | 42 | 333d |  |
| 44 |  | revised design | 30d | 2017-03-21 | 2017-05-01 | 43 | 333d |  |
| 45 |  | prototype | 60d | 2017-05-02 | 2017-07-24 | 44 | 333d |  |
| 46 |  | test | 20d | 2017-07-25 | 2017-08-21 | 45 | 842d |  |
| 47 |  | final design | 30d | 2017-08-22 | 2017-10-02 | 46 | 842d |  |
| 48 |  | Procure 4 FEMs | 60d | 2017-10-03 | 2017-12-25 | 47 | 842d |  |
| 49 |  | System Test | 30d | 2017-12-26 | 2018-02-05 | 48 | 842d |  |
| 50 | 1.3.3.2.11 | **sPHENIX Integration** | 180d | 2016-10-03 | 2017-06-09 |  | 364d |  |
| 51 |  | Slow Control Design | 60d | 2016-10-03 | 2016-12-23 |  | 364d |  |
| 52 |  | Trigger Interface Design | 60d | 2016-12-26 | 2017-03-17 | 51 | 364d |  |
| 53 |  | DAQ Interface Design | 60d | 2017-03-20 | 2017-06-09 | 52 | 364d |  |
| 54 | 1.3.3.3 | **Electronics Final Design Review** | 12d | 2018-02-06 | 2018-02-21 | 26, 39 | 842d |  |
| 55 |  | Electronics Design Review | 1d | 2018-02-06 | 2018-02-06 |  | 842d |  |
| 56 |  | Incorporate Review Comments | 10d | 2018-02-07 | 2018-02-20 | 55 | 842d |  |
| 57 |  | Electronics Design Review | 1d | 2018-02-21 | 2018-02-21 | 56 | 842d |  |
| 58 | 1.3.4 | **Ancillaries** | 60d | 2016-11-21 | 2017-02-10 | 18 | 449d |  |
| 59 |  | Procure LV,HV,etc | 60d | 2016-11-21 | 2017-02-10 |  | 449d | start no earlier than 2016-10-03 |
| 60 |  | Procure Racks | 60d | 2016-11-21 | 2017-02-10 |  | 449d | start no earlier than 2016-10-03 |
| 61 |  | Procure Chiller | 60d | 2016-11-21 | 2017-02-10 |  | 449d |  |
| 62 | 1.3.5 | **Mechanics** | 218d | 2016-10-03 | 2017-08-02 |  | 987d |  |
| 63 |  | obtain ALICE CAD model | 1d | 2016-10-03 | 2016-10-03 |  | 987d | start no earlier than 2016-06-01 |
| 64 | 1.3.5.2 | **Specifications** | 15d | 2016-10-04 | 2016-10-24 | 63 | 987d |  |
| 65 |  | review heat load | 5d | 2016-10-04 | 2016-10-10 |  | 987d | start no earlier than 2016-10-03 |
| 66 |  | review mechanical tolerances/distortions | 5d | 2016-10-11 | 2016-10-17 | 65 | 987d | start no earlier than 2004-10-01 |
| 67 |  | review disassembly/repair options | 5d | 2016-10-18 | 2016-10-24 | 66 | 987d | start no earlier than 2004-10-01 |
| 68 | 1.3.5.3 | **Support Structure & Global Interface to sPHENIX** | 145d | 2016-10-25 | 2017-05-15 | 64 | 987d |  |
| 69 |  | design | 60d | 2016-10-25 | 2017-01-16 | 67 | 987d | start no earlier than 2007-10-01 |
| 70 |  | prototype | 60d | 2017-01-17 | 2017-04-10 | 69 | 987d |  |

| ID | WBS | Task | Duration | Start | Finish | Predecessors | Total float | Constraint |
| --- | --- | --- | --- | --- | --- | --- | --- | --- |
| 71 |  | test | 10d | 2017-04-11 | 2017-04-24 | 70 | 987d |  |
| 72 |  | final design | 15d | 2017-04-25 | 2017-05-15 | 71 | 987d |  |
| 73 | 1.3.5.4 | **Cooling System** | 20d | 2016-10-25 | 2016-11-21 | 64 | 1092d |  |
| 74 |  | Design | 10d | 2016-10-25 | 2016-11-07 | 65 | 1092d |  |
| 75 |  | Mock up Testing | 10d | 2016-11-08 | 2016-11-21 | 74 | 1092d |  |
| 76 | 1.3.5.5 | **Safety Systems** | 65d | 2016-11-22 | 2017-02-20 | 73 | 1092d |  |
| 77 |  | review sensors & interlocks | 5d | 2016-11-22 | 2016-11-28 |  | 1092d |  |
| 78 |  | electrical interlock design | 30d | 2016-11-29 | 2017-01-09 | 77 | 1092d |  |
| 79 |  | cooling interlocks design | 30d | 2017-01-10 | 2017-02-20 | 78 | 1092d |  |
| 80 | 1.3.5.6 | **Tooling** | 45d | 2017-05-16 | 2017-07-17 | 68 | 987d |  |
| 81 |  | design | 10d | 2017-05-16 | 2017-05-29 |  | 987d |  |
| 82 |  | prototype | 30d | 2017-05-30 | 2017-07-10 | 81 | 987d |  |
| 83 |  | final design | 5d | 2017-07-11 | 2017-07-17 | 82 | 987d |  |
| 84 | 1.3.5.7 | **Mechanics Final Design Review** | 12d | 2017-07-18 | 2017-08-02 | 68, 73, 76, 80 | 987d |  |
| 85 |  | Mechanics Final Design Review | 1d | 2017-07-18 | 2017-07-18 |  | 987d |  |
| 86 |  | Incorporate Review Comments | 10d | 2017-07-19 | 2017-08-01 | 85 | 987d |  |
| 87 |  | Mechanical Design Review Complete | 1d | 2017-08-02 | 2017-08-02 | 86 | 987d |  |
| 88 | 1.4 | **Prototype Assembly** | 50d | 2017-12-11 | 2018-02-16 | 22, 58, 45 | 234d |  |
| 89 |  | Framing | 10d | 2017-12-11 | 2017-12-22 | 53 | 234d |  |
| 90 |  | Assemble prototype | 30d | 2017-12-25 | 2018-02-02 | 89 | 234d |  |
| 91 |  | Test prototype | 10d | 2018-02-02 | 2018-02-16 | 90 | 234d |  |
| 92 | 1.5 | **Test Beam Operation** | 35d | 2019-01-11 | 2019-02-28 | 88 | 0d |  |
| 93 |  | Shipping/Transport | 10d | 2019-01-11 | 2019-01-24 |  | 0d | as late as possible |
| 94 |  | Setup | 5d | 2019-01-25 | 2019-01-31 | 93 | 0d | as late as possible |
| 95 |  | Operations | 20d | 2019-02-01 | 2019-02-28 | 94 | 0d | must start on 2019-02-01 |
| 96 | 1.6 | **MAPS Inner Barrel Review** | 12d | 2018-02-22 | 2018-03-09 | 62, 25, 88 | 842d |  |
| 97 |  | Final Design Review | 1d | 2018-02-22 | 2018-02-22 |  | 842d |  |
| 98 |  | Incorporate Review Comments | 10d | 2018-02-23 | 2018-03-08 | 97 | 842d |  |
| 99 |  | Final Design Review | 1d | 2018-03-09 | 2018-03-09 | 98 | 842d |  |
| 100 | 1.7 | **Procurements** | 480d | 2018-08-01 | 2020-06-02 | 6 | 134d |  |
| 101 |  | Produce 58 Inner Staves | 150d | 2018-08-01 | 2019-02-26 |  | 344d | start no earlier than 2018-01-01 |
| 102 |  | Procure 100 SamTec Cables | 60d | 2018-08-01 | 2018-10-23 |  | 374d |  |
| 103 |  | Procure 58 Readout / FEM Units | 60d | 2019-02-27 | 2019-05-21 | 101 | 344d |  |
| 104 |  | Procure Optical Links | 60d | 2018-10-24 | 2019-01-15 | 102 | 374d |  |
| 105 |  | Procure 29 Common Readout Units | 60d | 2019-05-22 | 2019-08-13 | 103 | 344d |  |
| 106 |  | Procure Ancillary Materials | 60d | 2019-01-16 | 2019-04-09 | 104 | 374d |  |
| 107 |  | Procure Cooling Plant | 60d | 2019-04-10 | 2019-07-02 | 106 | 374d |  |
| 108 |  | Procure Assembly Fixtures & Jigs | 60d | 2018-08-01 | 2018-10-23 |  | 134d |  |
| 109 |  | Procure End Wheels | 60d | 2018-10-24 | 2019-01-15 | 108 | 134d |  |
| 110 |  | Procure Cylindrical Structural Shells | 60d | 2019-01-16 | 2019-04-09 | 109 | 134d |  |
| 111 |  | Procure Detector Half Barrels | 60d | 2019-04-10 | 2019-07-02 | 110 | 134d |  |
| 112 |  | Procure Service Half Barrels | 60d | 2019-07-03 | 2019-09-24 | 111 | 134d |  |
| 113 |  | Procure Detector and Service Half Barrels | 60d | 2019-09-25 | 2019-12-17 | 112 | 134d |  |
| 114 |  | Procure Two Half Support Structures | 120d | 2019-12-18 | 2020-06-02 | 113 | 134d |  |
| 115 | 1.8 | **Assembly and Testing** | 450d | 2019-02-27 | 2020-11-17 |  | 134d |  |
| 116 |  | Stave Reciept Inspection | 10d | 2019-02-27 | 2019-03-12 | 101 | 374d |  |
| 117 |  | Individual Stave Readout Test | 60d | 2019-03-13 | 2019-06-04 | 116 | 374d |  |
| 118 |  | Metrology on Stave Assemblies | 20d | 2019-06-05 | 2019-07-02 | 117 | 374d |  |
| 119 |  | Assemble full Ladders into Half support | 100d | 2020-06-03 | 2020-10-20 | 118, 100 | 134d |  |
| 120 |  | Metrology on Final Assembly | 10d | 2020-10-21 | 2020-11-03 | 119 | 134d |  |
| 121 |  | Test Half detector Assembly | 10d | 2020-11-04 | 2020-11-17 | 120 | 134d |  |
| 122 | 1.9 | **Installation** | 6d | 2020-11-18 | 2020-11-25 | 121 | 134d |  |
| 123 |  | Installation Prep | 5d | 2020-11-18 | 2020-11-24 | 121 | 134d |  |
| 124 |  | Installation Review | 1d | 2020-11-25 | 2020-11-25 | 123 | 134d |  |

## Version 2 (saved 2016-08-21, file MAPS_Inner_Barrel-2016_08_21_v1.mpp)

Last finish stays 2021-06-01.

Added:

| ID | Task | Duration | Start | Finish | Predecessors | Constraint | Resources |
| --- | --- | --- | --- | --- | --- | --- | --- |
| 2 | MAPS Inner Barrel Starts | 0d | 2016-10-01 | 2016-10-01 |  | must start on 2016-10-01 |  |
| 3 | MAPS Inner Barrel Ends | 0d | 2021-06-01 | 2021-06-01 |  | must finish on 2021-06-01 |  |
| 86 | **Mechanics Coneptual Design Review** | 12d | 2017-08-01 | 2017-08-16 | 70, 75, 78, 82 |  |  |
| 87 | Mechanics Design Review | 1d | 2017-08-01 | 2017-08-01 |  |  | Mechanical Engineer; Physicist |
| 98 | **sPHENIX Mechanics Integration** | 34d? | 2018-02-19 | 2018-04-05 | 93 |  |  |
| 99 | Final Mechanics Desgin | 30d? | 2018-02-23 | 2018-04-05 | 6SS+1d, 93FS+1d | start no earlier than 2018-02-23 | Mechanical Engineer [50%]; Physicist [10%] |
| 102 | Incorporate Review Comments | 10d | 2018-02-20 | 2018-03-05 | 101 |  | Mech Tech |
| 103 | Complete Final Mechanical Design | 1d | 2018-03-06 | 2018-03-06 | 102 |  | Physicist; Mechanical Engineer |
| 108 | **Productions** | 642d | 2018-08-01 | 2021-01-14 | 8, 107 |  |  |
| 109 | Full Mechnicas System pre-Production Mock Up and Test Beam Analysis | 100d | 2019-03-01 | 2019-07-18 | 8, 97 |  | Mechanical Engineer [20%]; Mech Tech [30%]; Physicist |
| 111 | **CERN Procuments** | 180d | 2018-08-01 | 2019-04-09 | 8SS |  |  |
| 113 | Other ITS/CERN items | 120d | 2018-08-01 | 2019-01-15 | 8 |  | Physicist [20%]; Mech Tech [2%] |
| 128 | Test Production FEMS, e-Links, CRU, LV, optical links | 90d | 2019-04-10 | 2019-08-13 | 114, 115, 116, 117, 118, 111 |  | Elec tech [30%]; Physicist [200%] |
| 129 | Test Cooling System | 10d | 2019-12-06 | 2019-12-19 | 119 |  | Mech Tech [50%]; Physicist [50%] |
| 139 | Installation | 60d | 2020-10-23 | 2021-01-14 | 138 |  | Physicist [200%]; Mech Tech; Elec tech |

Changed:

| ID | Task | Start | Finish | Duration | Complete | Total float | Predecessors | Other |
| --- | --- | --- | --- | --- | --- | --- | --- | --- |
| 1 | **MAPS Inner Barrel** | 2016-10-01 → 2016-10-03 (+2d) |  | 1218d → 1217d |  |  |  |  |
| 4 | **Milestones of sPHENIX** | 2016-10-01 → 2016-10-03 (+2d) |  |  |  | 0d → 1d |  | was named Milestones |
| 5 | sPHENIX Technical Design CD-0 | 2016-10-01 → 2016-11-01 (+31d) | 2016-10-01 → 2016-11-01 (+31d) |  |  | none → 1196d |  | was named sPHENIX Conceptual Design (CD-0); constraint start no earlier than 2016-10-01 → start no earlier than 2016-11-01 |
| 6 | sPHENIX Technical Design (CD-1/CD-3a) |  |  |  |  | none → 155d |  | was named sPHENIX Technical Design (CD-1) |
| 7 | sPHENIX Technical Dewsgin (CD-2) |  |  |  |  | none → 783d |  | was named sPHENIX Final Design (CD-2/CD-3a) |
| 10 | ALICE ITS Inner Barrel Construction |  |  |  |  | none → 234d |  | constraint finish no earlier than 2018-01-01 → start no earlier than 2017-01-02 |
| 11 | ALICE ITS Electronics Pre-Production |  |  |  |  | none → 421d |  | constraint finish no earlier than 2017-07-11 → start no earlier than 2017-02-22 |
| 12 | ALICE ITS Electronics Production |  |  |  |  | none → 774d |  | constraint start no earlier than 2017-07-12 → start no earlier than 2017-07-13 |
| 13 | LANL LDRD |  |  |  |  | none → 436d |  | constraint finish no earlier than 2019-09-30 → start no earlier than 2016-10-03 |
| 14 | sPHENIX Test Beam |  |  |  |  | none → 587d |  | constraint none → start no earlier than 2019-02-01 |
| 16 | Level 3 Project Manager |  |  |  |  |  |  | constraint finish no earlier than 2021-06-01 → start no earlier than 2016-10-03 |
| 19 | **Design & Prototyping** | 2016-10-03 A |  |  | 0% → 2% | 333d → 105d |  |  |
| 20 | **Readout Test Stand** | 2016-10-03 A | 2016-11-18 → 2016-12-30 (+42d) | 35d → 65d | 0% → 43% | 414d → 227d |  |  |
| 21 | Obtain Design from CERN |  | 2016-10-03 → 2016-10-07 (+4d) | 0d → 5d |  | 414d → 25d |  | was named Design; resources none → Electronics Engineer [20%] |
| 22 | Procure 2 Test Stands | 2016-10-03 A | 2016-11-11 → 2016-12-23 (+42d) | 30d → 60d | 0% → 50% | 414d → 384d |  | was named Procure 2 Stands |
| 23 | Setup Test Stands | 2016-11-14 → 2016-12-26 (+42d) | 2016-11-18 → 2016-12-30 (+42d) |  |  | 414d → 384d |  | was named Setup; resources Physicist; Elec tech [20%] → Physicist; Elec tech [50%] |
| 25 | Procure and Produce 4 Staves |  |  |  |  |  |  | was named Procure 4 Staves; resources Physicist [200%]; Elec tech → Physicist [200%]; Elec tech [50%] |
| 26 | Test Staves |  |  |  |  |  |  | resources Physicist → Physicist [200%] |
| 28 | **ALICE Readout Electronics** |  | 2017-10-05 → 2017-10-10 (+5d) | 264d → 267d |  | 929d → 189d |  |  |
| 29 | **SamTec Cables** |  | 2016-12-27 → 2016-10-18 (-70d) | 62d → 12d |  | 1007d → 367d |  |  |
| 30 | Procure 7 SamTec Cables |  | 2016-12-23 → 2016-10-14 (-70d) | 60d → 10d |  | 1007d → 599d |  | resources Physicist [20%]; Elec tech [10%] → Physicist [20%]; Elec tech [20%] |
| 31 | Test Cables | 2016-12-26 → 2016-10-17 (-70d) | 2016-12-27 → 2016-10-18 (-70d) |  |  | 1007d → 599d |  |  |
| 32 | **Readout Units (RDOs)** |  | 2017-10-05 → 2017-10-10 (+5d) | 62d → 65d |  | 929d → 189d |  |  |
| 33 | Procure 4 RDOs |  |  |  |  | 929d → 421d |  | resources Physicist [20%]; Elec tech [10%] → Physicist [10%]; Elec tech [5%] |
| 34 | Test RDOs |  | 2017-10-05 → 2017-10-10 (+5d) | 2d → 5d |  | 929d → 421d |  | resources Physicist → Physicist; Elec tech [30%] |
| 35 | **Optical Cables** | 2016-12-28 → 2016-10-19 (-70d) | 2017-03-23 → 2016-11-03 (-140d) | 62d → 12d |  | 1007d → 367d |  |  |
| 36 | Procure 4 Optical Cables | 2016-12-28 → 2016-10-19 (-70d) | 2017-03-21 → 2016-11-01 (-140d) | 60d → 10d |  | 1007d → 599d |  |  |
| 37 | Test Optical Cables | 2017-03-22 → 2016-11-02 (-140d) | 2017-03-23 → 2016-11-03 (-140d) |  |  | 1007d → 599d |  |  |
| 38 | **Common Readout Units (CRUs)** | 2017-03-24 → 2016-11-04 (-140d) | 2017-06-19 → 2017-02-02 (-137d) | 62d → 65d |  | 1007d → 367d |  |  |
| 39 | Procure 2 CRUs | 2017-03-24 → 2016-11-04 (-140d) | 2017-06-15 → 2017-01-26 (-140d) |  |  | 1007d → 599d |  | resources Physicist [20%]; Elec tech [10%] → Physicist [20%]; Elec tech [5%] |
| 40 | Test CRUs | 2017-06-16 → 2017-01-27 (-140d) | 2017-06-19 → 2017-02-02 (-137d) | 2d → 5d |  | 1007d → 599d |  | resources Physicist → Physicist; Elec tech [50%] |
| 41 | **sPHENIX Readout Electronics Integration (FEM)** |  |  |  |  | 333d → 105d |  | was named sPHENIX Readout Electronics |
| 42 | obtain ALICE Readout Unit design |  |  |  |  |  |  | resources Physicist; Electrical Engineer → Physicist; Electronics Engineer |
| 43 | initial design |  |  |  |  |  |  | resources Electronics Engineer → Electronics Engineer; Physicist [10%] |
| 44 | prototype |  |  |  |  |  |  | resources Physicist [20%]; Elec tech [10%] → Physicist [50%]; Elec tech [20%] |
| 45 | test-I |  |  |  |  |  |  | was named test; resources Electronics Engineer [33%]; Physicist [33%] → Electronics Engineer [30%]; Physicist [50%] |
| 46 | revised design |  |  |  |  |  |  | resources Electronics Engineer → Electronics Engineer; Physicist [20%] |
| 47 | prototype |  |  |  |  |  |  | resources Physicist [20%]; Elec tech [10%] → Physicist [50%]; Elec tech [20%] |
| 48 | test-II |  |  |  |  | 842d → 337d |  | was named test; resources Electronics Engineer [33%]; Physicist [33%] → Electronics Engineer [30%]; Physicist |
| 49 | final design |  |  |  |  | 842d → 337d |  | resources Electronics Engineer → Electronics Engineer; Physicist [20%] |
| 50 | Procure 4 FEMs |  |  |  |  | 842d → 337d |  | resources Physicist [20%]; Elec tech [10%] → Physicist [20%]; Elec tech [5%] |
| 51 | System Test |  |  |  |  | 842d → 337d |  | resources Electronics Engineer [33%]; Physicist [33%] → Electronics Engineer [30%]; Physicist |
| 52 | **sPHENIX DAQ System Integration** |  |  |  |  | 364d → 207d |  | was named sPHENIX Integration |
| 53 | Slow Control Design |  |  |  |  |  |  | resources Physicist [33%]; Electronics Engineer [33%] → Physicist [50%]; Electronics Engineer [30%] |
| 54 | Trigger Interface Design |  |  |  |  |  |  | resources Physicist [33%]; Electronics Engineer [33%] → Physicist [50%]; Electronics Engineer [30%] |
| 55 | DAQ Interface Design |  |  |  |  |  |  | resources Physicist [33%]; Electronics Engineer [33%] → Physicist [50%]; Electronics Engineer [30%] |
| 58 | Incorporate Review Comments |  |  |  |  | 842d → 337d |  | resources Elec tech → Elec tech; Physicist [20%] |
| 59 | Complete Final Electronics Design |  |  |  |  | 842d → 337d |  | was named Electronics Design Review |
| 60 | **Ancillaries** | 2016-11-21 → 2017-01-02 (+42d) | 2017-02-10 → 2017-03-30 (+48d) | 60d → 64d |  | 449d → 258d |  |  |
| 61 | Procure LV,HV,etc | 2016-11-21 → 2017-01-02 (+42d) | 2017-02-10 → 2017-03-24 (+42d) |  |  | 449d → 258d |  | resources Physicist [20%]; Elec tech [10%] → Physicist [10%]; Elec tech [10%] |
| 62 | Procure Racks | 2016-11-21 → 2017-01-04 (+44d) | 2017-02-10 → 2017-03-28 (+46d) |  |  | 449d → 258d | none → 61SS+2d | resources Physicist [20%]; Elec tech [10%] → Physicist [10%]; Elec tech [5%] |
| 63 | Procure Chiller | 2016-11-21 → 2017-01-06 (+46d) | 2017-02-10 → 2017-03-30 (+48d) |  |  | 449d → 258d | none → 62SS+2d | resources Physicist [20%]; Elec tech [10%] → Physicist [10%]; Elec tech [5%] |
| 64 | **Mechanics** |  | 2017-08-02 → 2017-08-16 (+14d) | 218d → 228d |  | 987d → 240d |  |  |
| 66 | **Specifications** |  | 2016-10-24 → 2016-12-19 (+56d) | 15d → 55d |  | 987d → 240d |  |  |
| 67 | review heat load |  | 2016-10-10 → 2016-11-28 (+49d) | 5d → 40d |  | 987d → 977d |  | resources Mechanical Engineer → Mechanical Engineer [50%] |
| 68 | review mechanical tolerances/distortions | 2016-10-11 → 2016-11-29 (+49d) | 2016-10-17 → 2016-12-12 (+56d) | 5d → 10d |  | 987d → 977d |  |  |
| 69 | review disassembly/repair options | 2016-10-18 → 2016-12-13 (+56d) | 2016-10-24 → 2016-12-19 (+56d) |  |  | 987d → 977d |  |  |
| 70 | **Stave Support Frame & Global Interface to sPHENIX** | 2016-10-25 → 2016-12-20 (+56d) | 2017-05-15 → 2017-05-29 (+14d) | 145d → 115d |  | 987d → 240d |  | was named Support Structure & Global Interface to sPHENIX |
| 71 | initial design | 2016-10-25 → 2016-12-20 (+56d) | 2017-01-16 → 2017-01-30 (+14d) | 60d → 30d |  | 987d → 977d |  | was named design; resources Mechanical Engineer → Mechanical Engineer; Physicist [20%] |
| 72 | prototype | 2017-01-17 → 2017-01-31 (+14d) | 2017-04-10 → 2017-04-24 (+14d) |  |  | 987d → 977d |  | resources none → Mech Tech [30%]; Physicist |
| 73 | test | 2017-04-11 → 2017-04-25 (+14d) | 2017-04-24 → 2017-05-08 (+14d) |  |  | 987d → 977d |  | resources Mech Tech → Mech Tech; Physicist [50%] |
| 74 | final design | 2017-04-25 → 2017-05-09 (+14d) | 2017-05-15 → 2017-05-29 (+14d) |  |  | 987d → 977d |  |  |
| 75 | **Cooling System** | 2016-10-25 → 2016-12-20 (+56d) | 2016-11-21 → 2017-01-16 (+56d) |  |  | 1092d → 310d |  |  |
| 76 | Design | 2016-10-25 → 2016-12-20 (+56d) | 2016-11-07 → 2017-01-02 (+56d) |  |  | 1092d → 1047d |  |  |
| 77 | Mock up Testing | 2016-11-08 → 2017-01-03 (+56d) | 2016-11-21 → 2017-01-16 (+56d) |  |  | 1092d → 1047d |  | resources Mech Tech [33%] → Mech Tech [50%] |
| 78 | **Safety Systems** | 2016-11-22 → 2017-01-17 (+56d) | 2017-02-20 → 2017-04-24 (+63d) | 65d → 70d |  | 1092d → 310d |  |  |
| 79 | review sensors & interlocks | 2016-11-22 → 2017-01-17 (+56d) | 2016-11-28 → 2017-01-30 (+63d) | 5d → 10d |  | 1092d → 1047d |  | resources Mechanical Engineer → Mechanical Engineer [50%] |
| 80 | electrical interlock design | 2016-11-29 → 2017-01-31 (+63d) | 2017-01-09 → 2017-03-13 (+63d) |  |  | 1092d → 1047d |  | resources Electronics Engineer → Electronics Engineer [30%] |
| 81 | cooling interlocks design | 2017-01-10 → 2017-03-14 (+63d) | 2017-02-20 → 2017-04-24 (+63d) |  |  | 1092d → 1047d |  | resources Mechanical Engineer → Mechanical Engineer [30%] |
| 82 | **Stave Assembly Tooling** | 2017-05-16 → 2017-05-30 (+14d) | 2017-07-17 → 2017-07-31 (+14d) |  |  | 987d → 240d |  | was named Tooling |

| ID | Task | Start | Finish | Duration | Total float | Predecessors | Other |
| --- | --- | --- | --- | --- | --- | --- | --- |
| 83 | design | 2017-05-16 → 2017-05-30 (+14d) | 2017-05-29 → 2017-06-12 (+14d) |  | 987d → 977d |  |  |
| 84 | prototype | 2017-05-30 → 2017-06-13 (+14d) | 2017-07-10 → 2017-07-24 (+14d) |  | 987d → 977d |  | resources Physicist [20%]; Mech Tech [10%] → Physicist [30%]; Mech Tech [20%] |
| 85 | final design | 2017-07-11 → 2017-07-25 (+14d) | 2017-07-17 → 2017-07-31 (+14d) |  | 987d → 977d |  |  |
| 88 | Incorporate Review Comments | 2017-07-19 → 2017-08-02 (+14d) | 2017-08-01 → 2017-08-15 (+14d) |  | 987d → 977d | 101 → 87 | resources Mech Tech → Mech Tech; Physicist [20%] |
| 89 | Complete Initall Mechanical Design (for CD-1) | 2017-08-02 → 2017-08-16 (+14d) | 2017-08-02 → 2017-08-16 (+14d) |  | 987d → 977d |  | was named Mechanical Design Review Complete |
| 91 | Stave Framing Design |  |  |  |  |  | was named Framing; resources Mech Tech [20%]; Physicist → Mech Tech [50%]; Physicist [30%] |
| 92 | Assemble prototype |  |  |  |  |  | resources Elec tech [33%]; Mech Tech [33%]; Physicist [33%] → Elec tech [50%]; Mech Tech [50%]; Physicist |
| 93 | Prototype Full System Test | 2018-02-02 → 2018-02-05 (+3d) |  |  |  |  | was named Test prototype; resources Physicist [33%]; Elec tech [33%]; Mech Tech [33%] → Physicist [200%]; Elec tech [50%]; Mech Tech [50%] |
| 100 | **Mechanics Final Design Review** | 2017-07-18 → 2018-02-19 (+216d) | 2017-08-02 → 2018-03-06 (+216d) |  | 987d → 96d |  |  |
| 101 | Mechanics Final Design Review | 2017-07-18 → 2018-02-19 (+216d) | 2017-07-18 → 2018-02-19 (+216d) |  | 987d → 833d |  |  |
| 104 | **MAPS Inner Barrel Review** | 2018-02-22 → 2018-04-06 (+43d) | 2018-03-09 → 2018-04-23 (+45d) |  | 842d → 74d | 64, 27, 90 → 64, 27, 90, 103 |  |
| 105 | Final Design Review | 2018-02-22 → 2018-04-06 (+43d) | 2018-02-22 → 2018-04-06 (+43d) |  | 842d → 74d | none → 98 |  |
| 106 | Incorporate Review Comments | 2018-02-23 → 2018-04-09 (+45d) | 2018-03-08 → 2018-04-20 (+43d) |  | 842d → 74d |  | resources Electronics Engineer; Mechanical Engineer; Physicist → Electronics Engineer [50%]; Mechanical Engineer [50%]; Physicist |
| 107 | Complete Final Design | 2018-03-09 → 2018-04-23 (+45d) | 2018-03-09 → 2018-04-23 (+45d) |  | 842d → 74d |  | was named Final Design Review |
| 110 | **Procurements** |  | 2020-06-02 → 2019-12-16 (-169d) | 480d → 359d | 134d → 3d |  |  |
| 112 | Produce 68 Inner Staves |  | 2019-02-26 → 2019-04-09 (+42d) | 150d → 180d | 344d → 223d | none → 59, 8 | was named Produce 58 Inner Staves; constraint start no earlier than 2018-01-01 → start no earlier than 2018-02-22; resources Physicist [200%]; Elec tech → Physicist [200%]; Elec tech [50%] |
| 114 | Procure 68 Readout / FEM Units | 2019-02-27 → 2018-08-02 (-209d) | 2019-05-21 → 2018-12-19 (-153d) | 60d → 100d | 344d → 370d | 112 → 8, 112SS+1d | was named Procure 58 Readout / FEM Units; resources Physicist [10%]; Elec tech [20%] → Physicist [10%]; Elec tech [10%] |
| 115 | Procure Optical Links 68 | 2018-10-24 → 2018-08-03 (-82d) | 2019-01-15 → 2018-10-25 (-82d) |  | 374d → 370d | 117 → 8, 114SS+1d | was named Procure Optical Links; resources Physicist [10%]; Elec tech [20%] → Physicist [10%]; Elec tech [5%] |
| 116 | Procure 34 Common Readout Units | 2019-05-22 → 2018-08-06 (-289d) | 2019-08-13 → 2018-12-21 (-235d) | 60d → 100d | 344d → none | 114 → 8, 115SS+1d | was named Procure 29 Common Readout Units; resources Physicist [10%]; Elec tech [20%] → Physicist [10%]; Elec tech [5%] |
| 117 | Procure 100 SamTec Cables | 2018-08-01 → 2018-08-07 (+6d) | 2018-10-23 → 2018-10-29 (+6d) |  | 374d → none | none → 8SS, 116SS+1d | resources Physicist [10%]; Elec tech [20%] → Physicist [10%]; Elec tech [5%] |
| 118 | Procure Ancillary Materials (LVPS and cables etc) | 2019-01-16 → 2018-08-08 (-161d) | 2019-04-09 → 2018-12-25 (-105d) | 60d → 100d | 374d → 368d | 115 → 117SS+1d, 8 | was named Procure Ancillary Materials; resources Physicist [10%]; Mech Tech [20%] → Physicist [10%]; Mech Tech [5%] |
| 119 | Procure Cooling Plant | 2019-04-10 → 2019-07-19 (+100d) | 2019-07-02 → 2019-12-05 (+156d) | 60d → 100d | 374d → 139d | 118 → 109, 8 | resources Physicist [10%]; Mech Tech [20%] → Physicist [10%]; Mech Tech [5%] |
| 120 | Procure Assembly Fixtures & Jigs | 2018-08-01 → 2019-07-22 (+355d) | 2018-10-23 → 2019-10-11 (+353d) |  | 134d → 139d | none → 109, 119SS+1d | resources Physicist [10%]; Mech Tech [20%] → Physicist [10%]; Mech Tech [5%] |
| 121 | Procure End Wheels | 2018-10-24 → 2019-07-23 (+272d) | 2019-01-15 → 2019-12-09 (+328d) | 60d → 100d | 134d → 139d | 120 → 109, 120SS+1d | resources Physicist [10%]; Mech Tech [20%] → Physicist [10%]; Mech Tech [5%] |
| 122 | Procure Cylindrical Structural Shells | 2019-01-16 → 2019-07-24 (+189d) | 2019-04-09 → 2019-12-10 (+245d) | 60d → 100d | 134d → 139d | 121 → 121SS+1d | resources Physicist [10%]; Mech Tech [20%] → Physicist [10%]; Mech Tech [5%] |
| 123 | Procure Detector Half Barrels | 2019-04-10 → 2019-07-25 (+106d) | 2019-07-02 → 2019-12-11 (+162d) | 60d → 100d | 134d → 139d | 122 → 122SS+1d | resources Physicist [10%]; Mech Tech [20%] → Physicist [10%]; Mech Tech [5%] |
| 124 | Procure Service Half Barrels | 2019-07-03 → 2019-07-26 (+23d) | 2019-09-24 → 2019-12-12 (+79d) | 60d → 100d | 134d → 139d | 123 → 123SS+1d | resources Physicist [10%]; Mech Tech [20%] → Physicist [10%]; Mech Tech [5%] |
| 125 | Procure Detector and Service Half Barrels | 2019-09-25 → 2019-07-29 (-58d) | 2019-12-17 → 2019-12-13 (-4d) | 60d → 100d | 134d → 139d | 124 → 124SS+1d | resources Physicist [10%]; Mech Tech [20%] → Physicist [10%]; Mech Tech [5%] |
| 126 | Procure Two Half Support Structures | 2019-12-18 → 2019-07-30 (-141d) | 2020-06-02 → 2019-12-16 (-169d) | 120d → 100d | 134d → 139d | 125 → 125SS+1d | resources Physicist [10%]; Mech Tech [20%] → Physicist [10%]; Mech Tech [5%] |
| 127 | **Assembly and Testing at BNL** | 2019-02-27 → 2019-04-10 (+42d) | 2020-11-17 → 2020-10-07 (-41d) | 450d → 391d | 134d → 98d | none → 8, 111 | was named Assembly and Testing |
| 130 | Stave Reciept Inspection | 2019-02-27 → 2019-04-10 (+42d) | 2019-03-12 → 2019-04-23 (+42d) |  | 374d → 98d |  | resources Physicist; Elec tech [33%] → Physicist [20%]; Elec tech [10.8%] |
| 131 | Individual Stave Readout Test | 2019-03-13 → 2019-04-24 (+42d) | 2019-06-04 → 2019-11-05 (+154d) | 60d → 140d | 374d → 98d |  | resources Physicist; Elec tech [33%] → Physicist [300%]; Elec tech [20%] |
| 132 | Metrology on Stave Assemblies | 2019-06-05 → 2019-11-06 (+154d) | 2019-07-02 → 2020-02-11 (+224d) | 20d → 70d | 374d → 98d |  | resources Mechanical Engineer → Mechanical Engineer [30%] |
| 133 | Assemble full Ladders into Half support | 2020-06-03 → 2020-02-12 (-112d) | 2020-10-20 → 2020-06-30 (-112d) |  | 134d → 98d | 132, 110 → 132, 110, 126, 125, 124, 123, 122, 121, 120, 128 | resources Mech Tech; Physicist [33%] → Mech Tech [150%]; Physicist [200%] |
| 134 | Metrology on Final Assembly | 2020-10-21 → 2020-07-01 (-112d) | 2020-11-03 → 2020-07-14 (-112d) |  | 134d → 98d |  |  |
| 135 | Test Half detector Assembly | 2020-11-04 → 2020-07-16 (-111d) | 2020-11-17 → 2020-10-07 (-41d) | 10d → 60d | 134d → 98d | 134 → 134FS+1d, 128FS+1d | resources Physicist [33%]; Mech Tech → Physicist [200%]; Mech Tech; Elec tech |
| 136 | **Installation** | 2020-11-18 → 2020-10-08 (-41d) | 2020-11-25 → 2021-01-14 (+50d) | 6d → 71d | 134d → 98d |  |  |
| 137 | Installation Prep | 2020-11-18 → 2020-10-08 (-41d) | 2020-11-24 → 2020-10-21 (-34d) | 5d → 10d | 134d → 98d |  | resources Mech Tech → Mech Tech; Physicist |
| 138 | Installation Review | 2020-11-25 → 2020-10-22 (-34d) | 2020-11-25 → 2020-10-22 (-34d) |  | 134d → 98d |  | resources Physicist → Physicist; Mechanical Engineer |

## Version 3 (saved 2016-08-21, file MAPS_Inner_Barrel-2016_08_21_v2.mpp)

Last finish stays 2021-06-01.

Added:

| ID | Task | Duration | Start | Finish | Predecessors | Resources |
| --- | --- | --- | --- | --- | --- | --- |
| 20 | MOU btw LANL/sPHENIX and ALICE | 60d? | 2016-10-03 | 2016-12-23 |  | Physicist [10%] |
| 28 | Travel and Per Diem Support | 180d? | 2016-12-26 | 2017-09-01 | 26SS |  |
| 110 | Update MOU for Staev Production Extension ? | 30d? | 2018-07-03 | 2018-08-13 | 109 | Project Manager [20%] |
| 117 | Travel and Per Diem at CERN | 180d? | 2018-08-01 | 2019-04-09 | 115SS, 8 |  |
| 144 | Commissioning | 60d | 2020-11-19 | 2021-02-10 | 143 | Physicist [200%]; Mech Tech [20%]; Elec tech [20%] |
| 145 | Ready for beam | 0d | 2021-02-10 | 2021-02-10 | 144 |  |

Changed:

| ID | Task | Start | Finish | Duration | Total float | Predecessors | Other |
| --- | --- | --- | --- | --- | --- | --- | --- |
| 7 | sPHENIX Technical Dewsgin (CD-2) | 2018-06-01 → 2018-08-13 (+73d) | 2018-06-01 → 2018-08-13 (+73d) |  | 783d → 731d |  |  |
| 19 | **Design & Prototyping** |  |  | 363d → 363d? | 105d → 854d |  |  |
| 25 | **Detector Staves** | 2017-07-31 → 2016-12-26 (-217d) | 2017-12-08 → 2017-09-15 (-84d) | 95d → 190d? | 77d → 125d | 10SS+150d, 21 → none |  |
| 26 | Procure and Produce 4 Staves | 2017-07-31 → 2016-12-26 (-217d) | 2017-12-01 → 2017-09-01 (-91d) | 90d → 180d | 234d → 125d | none → 20, 21SS | resources Physicist [200%]; Elec tech [50%] → Physicist; Elec tech |
| 27 | Test Staves | 2017-12-04 → 2017-09-04 (-91d) | 2017-12-08 → 2017-09-15 (-84d) | 5d → 10d | 234d → 125d |  |  |
| 30 | **ALICE Readout Electronics** |  | 2017-10-10 → 2017-10-17 (+7d) | 267d → 272d | 189d → 184d |  |  |
| 34 | **Readout Units (RDOs)** |  | 2017-10-10 → 2017-10-17 (+7d) | 65d → 70d | 189d → 184d | 11 → none |  |
| 35 | Procure 4 RDOs |  |  |  | 421d → 184d | none → 32SS+1d, 11 |  |
| 36 | Test RDOs |  | 2017-10-10 → 2017-10-17 (+7d) | 5d → 10d | 421d → 184d |  |  |
| 37 | **Optical Cables** | 2016-10-19 → 2016-10-04 (-15d) | 2016-11-03 → 2016-10-19 (-15d) |  | 367d → 443d | 31 → none |  |
| 38 | Procure 4 Optical Cables | 2016-10-19 → 2016-10-04 (-15d) | 2016-11-01 → 2016-10-17 (-15d) |  | 599d → 443d | none → 32SS+1d |  |
| 39 | Test Optical Cables | 2016-11-02 → 2016-10-18 (-15d) | 2016-11-03 → 2016-10-19 (-15d) |  | 599d → 443d |  |  |
| 40 | **Common Readout Units (CRUs)** | 2016-11-04 → 2016-10-05 (-30d) | 2017-02-02 → 2017-01-03 (-30d) |  | 367d → 389d | 37 → none |  |
| 41 | Procure 2 CRUs | 2016-11-04 → 2016-10-05 (-30d) | 2017-01-26 → 2016-12-27 (-30d) |  | 599d → 389d | none → 37SS+1d |  |
| 42 | Test CRUs | 2017-01-27 → 2016-12-28 (-30d) | 2017-02-02 → 2017-01-03 (-30d) |  | 599d → 389d |  |  |
| 58 | **Electronics Final Design Review** |  |  |  |  | 30, 43 → none |  |
| 59 | Electronics Design Review |  |  |  | 337d → 105d | none → 30, 53 |  |
| 62 | **Ancillaries** | 2017-01-02 → 2016-10-04 (-90d) | 2017-03-30 → 2016-12-30 (-90d) |  | 258d → 310d | 21 → none |  |
| 63 | Procure LV,HV,etc | 2017-01-02 → 2016-10-04 (-90d) | 2017-03-24 → 2016-12-26 (-88d) |  | 258d → 310d | none → 21SS+1d |  |
| 64 | Procure Racks | 2017-01-04 → 2016-10-06 (-90d) | 2017-03-28 → 2016-12-28 (-90d) |  | 258d → 310d |  |  |
| 65 | Procure Chiller | 2017-01-06 → 2016-10-10 (-88d) | 2017-03-30 → 2016-12-30 (-90d) |  | 258d → 310d |  |  |
| 66 | **Mechanics** |  | 2017-08-16 → 2017-08-15 (-1d) | 228d → 227d | 240d → 211d |  |  |
| 67 | obtain ALICE CAD model |  |  | 1d → 0d | 977d → 211d |  |  |
| 68 | **Specifications** | 2016-10-04 → 2016-10-03 (-1d) | 2016-12-19 → 2016-12-16 (-3d) |  | 240d → 211d | 67 → none |  |
| 69 | review heat load | 2016-10-04 → 2016-10-03 (-1d) | 2016-11-28 → 2016-11-25 (-3d) |  | 977d → 211d | none → 67 |  |
| 70 | review mechanical tolerances/distortions | 2016-11-29 → 2016-11-28 (-1d) | 2016-12-12 → 2016-12-09 (-3d) |  | 977d → 211d |  |  |
| 71 | review disassembly/repair options | 2016-12-13 → 2016-12-12 (-1d) | 2016-12-19 → 2016-12-16 (-3d) |  | 977d → 211d |  |  |
| 72 | **Stave Support Frame & Global Interface to sPHENIX** | 2016-12-20 → 2016-12-19 (-1d) | 2017-05-29 → 2017-05-26 (-3d) |  | 240d → 211d | 68 → none |  |
| 73 | initial design | 2016-12-20 → 2016-12-19 (-1d) | 2017-01-30 → 2017-01-27 (-3d) |  | 977d → 211d |  |  |
| 74 | prototype | 2017-01-31 → 2017-01-30 (-1d) | 2017-04-24 → 2017-04-21 (-3d) |  | 977d → 211d |  |  |
| 75 | test | 2017-04-25 → 2017-04-24 (-1d) | 2017-05-08 → 2017-05-05 (-3d) |  | 977d → 211d |  |  |
| 76 | final design | 2017-05-09 → 2017-05-08 (-1d) | 2017-05-29 → 2017-05-26 (-3d) |  | 977d → 211d |  |  |
| 77 | **Cooling System** | 2016-12-20 → 2016-11-28 (-22d) | 2017-01-16 → 2016-12-23 (-24d) |  | 310d → 296d | 68 → none |  |
| 78 | Design | 2016-12-20 → 2016-11-28 (-22d) | 2017-01-02 → 2016-12-09 (-24d) |  | 1047d → 296d |  |  |
| 79 | Mock up Testing | 2017-01-03 → 2016-12-12 (-22d) | 2017-01-16 → 2016-12-23 (-24d) |  | 1047d → 296d |  |  |
| 80 | **Safety Systems** | 2017-01-17 → 2016-12-26 (-22d) | 2017-04-24 → 2017-03-31 (-24d) |  | 310d → 296d | 77 → none |  |
| 81 | review sensors & interlocks | 2017-01-17 → 2016-12-26 (-22d) | 2017-01-30 → 2017-01-06 (-24d) |  | 1047d → 296d | none → 79 |  |
| 82 | electrical interlock design | 2017-01-31 → 2017-01-09 (-22d) | 2017-03-13 → 2017-02-17 (-24d) |  | 1047d → 296d |  |  |
| 83 | cooling interlocks design | 2017-03-14 → 2017-02-20 (-22d) | 2017-04-24 → 2017-03-31 (-24d) |  | 1047d → 296d |  |  |
| 84 | **Stave Assembly Tooling** | 2017-05-30 → 2017-05-29 (-1d) | 2017-07-31 → 2017-07-28 (-3d) |  | 240d → 211d | 72 → none |  |
| 85 | design | 2017-05-30 → 2017-05-29 (-1d) | 2017-06-12 → 2017-06-09 (-3d) |  | 977d → 211d | none → 76 |  |
| 86 | prototype | 2017-06-13 → 2017-06-12 (-1d) | 2017-07-24 → 2017-07-21 (-3d) |  | 977d → 211d |  |  |
| 87 | final design | 2017-07-25 → 2017-07-24 (-1d) | 2017-07-31 → 2017-07-28 (-3d) |  | 977d → 211d |  |  |
| 88 | **Mechanics Coneptual Design Review** | 2017-08-01 → 2017-07-31 (-1d) | 2017-08-16 → 2017-08-15 (-1d) |  | 240d → 241d | 72, 77, 80, 84 → none |  |
| 89 | Mechanics Design Review | 2017-08-01 → 2017-07-31 (-1d) | 2017-08-01 → 2017-07-31 (-1d) |  | 977d → 241d | none → 76, 79, 83, 87 |  |
| 90 | Incorporate Review Comments | 2017-08-02 → 2017-08-01 (-1d) | 2017-08-15 → 2017-08-14 (-1d) |  | 977d → 241d |  |  |
| 91 | Complete Initall Mechanical Design (for CD-1) | 2017-08-16 → 2017-08-15 (-1d) | 2017-08-16 → 2017-08-15 (-1d) |  | 977d → 241d |  |  |
| 92 | **Prototype Assembly** | 2017-12-11 → 2018-02-06 (+57d) | 2018-02-16 → 2018-04-16 (+59d) |  | 77d → 24d | 25, 62, 49 → none |  |
| 93 | Stave Framing Design | 2017-12-11 → 2018-02-06 (+57d) | 2017-12-22 → 2018-02-19 (+59d) |  | 234d → 24d | 57 → 57, 27, 65, 53 |  |
| 94 | Assemble prototype | 2017-12-25 → 2018-02-20 (+57d) | 2018-02-02 → 2018-04-02 (+59d) |  | 234d → 24d |  |  |
| 95 | Prototype Full System Test | 2018-02-05 → 2018-04-03 (+57d) | 2018-02-16 → 2018-04-16 (+59d) |  | 234d → 24d |  |  |
| 96 | **Test Beam Operation** |  |  |  |  | 92 → none |  |
| 97 | Shipping/Transport |  |  |  |  | none → 95 |  |
| 100 | **sPHENIX Mechanics Integration** | 2018-02-19 → 2018-04-18 (+58d) | 2018-04-05 → 2018-06-14 (+70d) | 34d? → 42d? | 74d → 24d | 95 → none |  |
| 101 | Final Mechanics Desgin | 2018-02-23 → 2018-04-18 (+54d) | 2018-04-05 → 2018-05-29 (+54d) |  | 811d → 24d | 6SS+1d, 95FS+1d → 6SS+1d, 95FS+1d, 76, 79, 83, 87 |  |
| 102 | **Mechanics Final Design Review** | 2018-02-19 → 2018-05-30 (+100d) | 2018-03-06 → 2018-06-14 (+100d) |  | 96d → 24d | 72, 77, 80, 84 → none |  |
| 103 | Mechanics Final Design Review | 2018-02-19 → 2018-05-30 (+100d) | 2018-02-19 → 2018-05-30 (+100d) |  | 833d → 24d | none → 101 |  |
| 104 | Incorporate Review Comments | 2018-02-20 → 2018-05-31 (+100d) | 2018-03-05 → 2018-06-13 (+100d) |  | 833d → 24d |  |  |
| 105 | Complete Final Mechanical Design | 2018-03-06 → 2018-06-14 (+100d) | 2018-03-06 → 2018-06-14 (+100d) |  | 833d → 24d |  |  |
| 106 | **MAPS Inner Barrel Review** | 2018-04-06 → 2018-06-15 (+70d) | 2018-04-23 → 2018-08-13 (+112d) | 12d → 42d? | 74d → 24d | 66, 29, 92, 105 → none |  |
| 107 | Final Design Review | 2018-04-06 → 2018-06-15 (+70d) | 2018-04-06 → 2018-06-15 (+70d) |  | 74d → 24d | 100 → 91, 61, 95, 105 |  |
| 108 | Incorporate Review Comments | 2018-04-09 → 2018-06-18 (+70d) | 2018-04-20 → 2018-06-29 (+70d) |  | 74d → 24d |  |  |
| 109 | Complete Final Design (CD-2) | 2018-04-23 → 2018-07-02 (+70d) | 2018-04-23 → 2018-07-02 (+70d) |  | 74d → 24d |  | was named Complete Final Design |
| 111 | **Productions** |  | 2021-01-14 → 2021-02-10 (+27d) | 642d → 661d? |  |  |  |
| 112 | Full Mechnicas System pre-Production Mock Up and Test Beam Analysis |  |  |  | 139d → 79d | 8, 99 → 8, 99, 109 |  |
| 113 | **Procurements** |  |  | 359d → 359d? |  | 8 → none |  |
| 114 | **CERN Procuments** |  |  | 180d → 180d? | 98d → 108d | 8SS → none |  |
| 131 | **Assembly and Testing at BNL** | 2019-04-10 → 2018-12-26 (-105d) | 2020-10-07 → 2020-08-11 (-57d) | 391d → 425d | 98d → 183d | 8, 114 → none |  |
| 132 | Test Production FEMS, e-Links, CRU, LV, optical links | 2019-04-10 → 2018-12-26 (-105d) | 2019-08-13 → 2019-04-30 (-105d) |  | 228d → 243d | 118, 119, 120, 121, 122, 114 → 118, 119, 120, 121, 122 |  |
| 135 | Individual Stave Readout Test |  | 2019-11-05 → 2019-07-30 (-98d) | 140d → 70d | 98d → 108d |  |  |

| ID | Task | Start | Finish | Duration | Total float | Predecessors |
| --- | --- | --- | --- | --- | --- | --- |
| 136 | Metrology on Stave Assemblies | 2019-11-06 → 2019-07-31 (-98d) | 2020-02-11 → 2019-11-05 (-98d) |  | 98d → 108d |  |
| 137 | Assemble full Ladders into Half support | 2020-02-12 → 2019-12-17 (-57d) | 2020-06-30 → 2020-05-04 (-57d) |  | 98d → 79d |  |
| 138 | Metrology on Final Assembly | 2020-07-01 → 2020-05-05 (-57d) | 2020-07-14 → 2020-05-18 (-57d) |  | 98d → 79d |  |
| 139 | Test Half detector Assembly | 2020-07-16 → 2020-05-20 (-57d) | 2020-10-07 → 2020-08-11 (-57d) |  | 98d → 79d |  |
| 140 | **Installation** | 2020-10-08 → 2020-08-12 (-57d) | 2021-01-14 → 2021-02-10 (+27d) | 71d → 131d | 98d → 79d | 139 → none |
| 141 | Installation Prep | 2020-10-08 → 2020-08-12 (-57d) | 2020-10-21 → 2020-08-25 (-57d) |  | 98d → 79d |  |
| 142 | Installation Review | 2020-10-22 → 2020-08-26 (-57d) | 2020-10-22 → 2020-08-26 (-57d) |  | 98d → 79d |  |
| 143 | Installation | 2020-10-23 → 2020-08-27 (-57d) | 2021-01-14 → 2020-11-18 (-57d) |  | 98d → 79d |  |

## Version 4 (saved 2016-08-22, file MAPS_Inner_Barrel-2016_08_21a.mpp)

Last finish stays 2021-06-01.

Removed: 110 Update MOU for Staev Production Extension ?

Changed:

| ID | Task | Start | Finish | Duration | Total float |
| --- | --- | --- | --- | --- | --- |
| 7 | sPHENIX Technical Dewsgin (CD-2) | 2018-08-13 → 2018-07-02 (-42d) | 2018-08-13 → 2018-07-02 (-42d) |  | 731d → 761d |
| 106 | **MAPS Inner Barrel Review** |  | 2018-08-13 → 2018-07-02 (-42d) | 42d? → 12d |  |
